# Dorado2002

Schedule from MS Project, 2002-03-15 to 2002-08-21.
KEE Systems

## Calendars

- Standard: Mon-Fri 08:00-12:00, 13:00-17:00; Sat-Sun off.

## Resources

| Resource |
| --- |
| Hans |
| Drew |
| Sib |
| Farley |
| ME |
| Rob |
| Rich |
| Craig |
| Kent |
| ME TECH |
| EE TECH |
| Shop |
| Kiwi |

## Schedule

| ID | WBS | Task | Duration | Start | Finish | Predecessors | Total slack | Free slack | Constraint | Resources | Work |
| --- | --- | --- | --- | --- | --- | --- | --- | --- | --- | --- | --- |
| 1 | 1 | **Dorado Program** | 114d? | 2002-03-15 | 2002-08-21 |  | 0d |  |  |  | 13880h |
| 3 | 1.1 | **Propulsion** | 26d | 2002-03-15 | 2002-04-19 |  | 34d |  |  |  | 608h |
| 4 | 1.1.1 | **Articulated Tail** | 21d | 2002-03-15 | 2002-04-12 |  | 34d | 0d |  |  | 248h |
| 5 | 1.1.1.1 | Design & Build New Electronics Housing | 10d | 2002-03-15 | 2002-03-28 |  | 45d |  |  | Farley | 80h |
| 6 | 1.1.1.2 | New Linear Actuator Scheme | 21d | 2002-03-15 | 2002-04-12 |  | 34d |  |  | Hans | 168h |
| 7 | 1.1.2 | **Drive Electronics** | 15d | 2002-03-15 | 2002-04-04 |  | 39d | 0d |  |  | 160h |
| 8 | 1.1.2.1 | Integrate New Electroincs | 15d | 2002-03-15 | 2002-04-04 |  | 39d |  |  | Sib | 120h |
| 9 | 1.1.2.2 | Cabling | 5d | 2002-03-28 | 2002-04-03 |  | 40d |  | start no earlier than 2002-03-28 | EE TECH | 40h |
| 10 | 1.1.3 | Integrate New Tail Into fairing | 5d | 2002-04-05 | 2002-04-11 | 7 | 39d | 0d |  | Farley | 40h |
| 11 | 1.1.4 | Tailcone - Bench Stand Design and Fab | 3d | 2002-03-15 | 2002-03-19 |  | 57d |  |  | ME TECH | 24h |
| 12 | 1.1.5 | Buoyancy Check / Test | 1d | 2002-04-12 | 2002-04-12 | 10 | 39d |  |  | Drew | 8h |
| 13 | 1.1.6 | Test Plan | 5d | 2002-04-08 | 2002-04-12 |  | 39d |  | start no earlier than 2002-04-08 | Rob | 40h |
| 14 | 1.1.7 | **Tailcone Documetation** | 5d | 2002-04-15 | 2002-04-19 | 7, 4 | 34d |  |  |  | 88h |
| 15 | 1.1.7.1 | Mechanical | 3d | 2002-04-15 | 2002-04-17 |  | 36d |  |  | Farley | 24h |
| 16 | 1.1.7.2 | Electrical | 3d | 2002-04-15 | 2002-04-17 |  | 36d |  |  | Sib | 24h |
| 17 | 1.1.7.3 | Software | 5d | 2002-04-15 | 2002-04-19 |  | 34d |  |  | Sib | 40h |
| 19 | 1.2 | **Power** | 36d? | 2002-03-15 | 2002-05-03 |  | 21d |  |  | Hans | 1704h |
| 20 | 1.2.1 | **Battery Chemistry** | 27d | 2002-03-15 | 2002-04-22 |  | 21d |  |  | Hans | 488h |
| 21 | 1.2.1.1 | Check life on current Ag-Zn batteries | 4d | 2002-03-15 | 2002-03-20 |  | 22d | 1d |  | Hans | 32h |
| 22 | 1.2.1.2 | Trade study to review Batt Chems | 3d | 2002-03-15 | 2002-03-19 |  | 23d | 2d |  | Hans | 24h |
| 23 | 1.2.1.3 | Thermal Analysis of Battery Pack | 5d | 2002-03-15 | 2002-03-21 |  | 21d | 0d |  | Kiwi | 40h |
| 24 | 1.2.1.4 | Design Review of Batt Chems | 1d | 2002-03-22 | 2002-03-22 | 21, 22, 23 | 21d | 0d |  | Hans | 8h |
| 25 | 1.2.1.5 | Purchase Batteries | 1d | 2002-03-25 | 2002-03-25 | 24 | 83d | 0d |  | Hans | 8h |
| 26 | 1.2.1.6 | Assemble Batteries | 5d | 2002-03-26 | 2002-04-01 | 25 | 83d | 0d |  | EE TECH | 40h |
| 27 | 1.2.1.7 | Test Batteries | 15d | 2002-04-02 | 2002-04-22 | 26 | 83d | 0d |  | EE TECH | 120h |

| ID | WBS | Task | Duration | Start | Finish | Predecessors | Total slack | Free slack | Constraint | Resources | Work |
| --- | --- | --- | --- | --- | --- | --- | --- | --- | --- | --- | --- |
| 28 | 1.2.2 | **Battery Housing** | 30d | 2002-03-25 | 2002-05-03 | 24 | 78d |  |  | Hans | 520h |
| 29 | 1.2.2.1 | Design | 10d | 2002-03-25 | 2002-04-05 |  | 78d | 0d |  | Craig | 80h |
| 30 | 1.2.2.2 | Build | 15d | 2002-04-08 | 2002-04-26 | 29 | 78d | 0d |  | ME TECH | 120h |
| 31 | 1.2.2.3 | Test | 5d | 2002-04-29 | 2002-05-03 | 30 | 78d |  |  | Craig | 40h |
| 32 | 1.2.2.4 | Spec Interconnects | 5d | 2002-03-25 | 2002-03-29 |  | 80d | 0d |  | Sib | 40h |
| 33 | 1.2.3 | **Battery Electronics** | 20d? | 2002-04-01 | 2002-04-26 | 24, 32 | 80d | 0d |  | Sib | 328h |
| 34 | 1.2.3.1 | Concept Design | 5d | 2002-04-01 | 2002-04-05 |  | 80d | 0d |  | Sib | 40h |
| 35 | 1.2.3.2 | Design Review | 2d | 2002-04-08 | 2002-04-09 | 34 | 80d | 0d |  | Sib | 16h |
| 36 | 1.2.3.3 | Final Design | 10d | 2002-04-10 | 2002-04-23 | 35 | 80d | 0d |  | Sib | 80h |
| 37 | 1.2.3.4 | Build | 1d | 2002-04-24 | 2002-04-24 | 36 | 80d | 0d |  | EE TECH | 8h |
| 38 | 1.2.3.5 | Assemble | 1d | 2002-04-25 | 2002-04-25 | 37 | 80d | 0d |  | EE TECH | 8h |
| 39 | 1.2.3.6 | Test | 1d | 2002-04-26 | 2002-04-26 | 38 | 80d |  |  | EE TECH | 8h |
| 40 | 1.2.3.7 | Spec Misc Electronics (Contingency) | 1d? | 2002-04-23 | 2002-04-23 | 27 | 83d |  |  | Sib | 8h |
| 41 | 1.2.4 | **Battery Charging** | 3d | 2002-04-29 | 2002-05-01 | 24, 33 | 80d |  |  | Hans | 56h |
| 42 | 1.2.4.1 | Spec Charging Analysis | 3d | 2002-04-29 | 2002-05-01 |  | 80d |  |  | Hans | 24h |
| 43 | 1.2.4.2 | Order Charging Equip as Required | 1d | 2002-04-29 | 2002-04-29 |  | 82d |  |  | Hans | 8h |
| 44 | 1.2.5 | AUV Power Systems Meeting | 3d | 2002-04-26 | 2002-04-30 |  | 81d |  | start no earlier than 2002-04-26 | Hans | 24h |
| 46 | 1.3 | **Cabling and Connectors** | 14d | 2002-03-25 | 2002-04-11 | 24 | 40d |  |  | Drew | 328h |
| 47 | 1.3.1 | Spec Main Power / Comms Cable&Connectors/Penetrators | 2d | 2002-03-25 | 2002-03-26 |  | 46d | 0d |  | Hans | 16h |
| 48 | 1.3.2 | Spec Charging Connector | 2d | 2002-03-27 | 2002-03-28 | 47 | 50d |  |  | Hans | 16h |
| 49 | 1.3.3 | Spec Tailcone Comms Cable&Connector/Penetrator | 3d | 2002-03-25 | 2002-03-27 |  | 45d | 5d |  | Sib | 24h |
| 50 | 1.3.4 | Spec Science Instrument Connector | 2d | 2002-03-25 | 2002-03-26 |  | 40d | 0d |  | Drew | 16h |
| 51 | 1.3.5 | Spec DVL and parosci Connectors / Penetrator | 2d | 2002-03-27 | 2002-03-28 | 50 | 40d | 0d |  | Drew | 16h |
| 52 | 1.3.6 | Spec RF/Acoustic/Emer location Connect & Penetrators | 2d | 2002-03-29 | 2002-04-01 | 51 | 40d | 0d |  | Drew | 16h |
| 53 | 1.3.7 | Spec On/Off Connector/Penetrator | 2d | 2002-04-02 | 2002-04-03 | 52 | 40d | 0d |  | Drew | 16h |
| 54 | 1.3.8 | Test ability of 100 MB/s thrugh current ALTEX Cable | 2d | 2002-03-25 | 2002-03-26 |  | 52d |  |  | Drew | 16h |
| 55 | 1.3.9 | Order Connectors | 1d | 2002-04-04 | 2002-04-04 | 47, 49, 53 | 40d | 0d |  | Drew | 8h |

| ID | WBS | Task | Duration | Start | Finish | Predecessors | Total slack | Free slack | Resources | Work |
| --- | --- | --- | --- | --- | --- | --- | --- | --- | --- | --- |
| 56 | 1.3.10 | **Tail to MVC** | 2d | 2002-03-25 | 2002-03-26 |  | 47d |  | Drew | 32h |
| 57 | 1.3.10.1 | Section Interconnect | 2d | 2002-03-25 | 2002-03-26 |  | 47d | 7d | Drew | 16h |
| 58 | 1.3.11 | Documetation package on Connectors and Cabling | 5d | 2002-04-05 | 2002-04-11 | 55, 57 | 40d |  | Drew | 40h |
| 60 | 1.4 | **Main Vehicle Computer** | 39d? | 2002-03-15 | 2002-05-08 |  | 21d |  | Sib | 2160h |
| 61 | 1.4.1 | **Electronics** | 29d | 2002-03-15 | 2002-04-24 |  | 27d |  | Sib | 1288h |
| 62 | 1.4.1.1 | Spec PC 104 Stack | 2d | 2002-03-15 | 2002-03-18 |  | 55d | 0d | Sib | 16h |
| 63 | 1.4.1.2 | Order PC 104 Stack | 1d | 2002-03-19 | 2002-03-19 | 62 | 55d | 0d | Sib | 8h |
| 64 | 1.4.1.3 | Assemble PC 104 Stack | 2d | 2002-03-20 | 2002-03-21 | 63 | 55d |  | EE TECH | 16h |
| 65 | 1.4.1.4 | Develop latency test/budget for MVC | 2d | 2002-03-15 | 2002-03-18 |  | 58d |  | Sib | 16h |
| 66 | 1.4.1.5 | **Power Board** | 23d | 2002-03-25 | 2002-04-24 | 24 | 21d | 0d | Sib | 368h |
| 67 | 1.4.1.5.1 | Specify | 4d | 2002-03-25 | 2002-03-28 |  | 21d | 0d | Sib | 32h |
| 68 | 1.4.1.5.2 | Design | 15d | 2002-03-29 | 2002-04-18 | 67 | 21d | 0d | Sib | 120h |
| 69 | 1.4.1.5.3 | Order | 1d | 2002-04-19 | 2002-04-19 | 68 | 21d | 0d | Sib | 8h |
| 70 | 1.4.1.5.4 | Build | 2d | 2002-04-22 | 2002-04-23 | 69 | 21d | 0d | EE TECH | 16h |
| 71 | 1.4.1.5.5 | Test | 1d | 2002-04-24 | 2002-04-24 | 70 | 21d |  | EE TECH | 8h |
| 72 | 1.4.1.6 | **RF Modem** | 5d | 2002-03-15 | 2002-03-21 |  | 55d |  | Drew | 80h |
| 73 | 1.4.1.6.1 | Evaluate Data-link vs Freewave | 4d | 2002-03-15 | 2002-03-20 |  | 55d | 0d | Drew | 32h |
| 74 | 1.4.1.6.2 | Purchase | 1d | 2002-03-21 | 2002-03-21 | 73 | 55d |  | Drew | 8h |
| 75 | 1.4.1.7 | **Acoustic Modem** | 10d | 2002-03-15 | 2002-03-28 |  | 40d | 19d | Hans | 160h |
| 76 | 1.4.1.7.1 | Evaluate | 9d | 2002-03-15 | 2002-03-27 |  | 40d | 0d | Hans | 72h |
| 77 | 1.4.1.7.2 | Purchase | 1d | 2002-03-28 | 2002-03-28 | 76 | 40d |  | Hans | 8h |
| 78 | 1.4.1.8 | **GPS** | 15d | 2002-03-15 | 2002-04-04 |  | 35d | 14d | Drew | 240h |
| 79 | 1.4.1.8.1 | Evaluate GPS Position Fix Problem | 10d | 2002-03-15 | 2002-03-28 |  | 35d | 0d | Craig | 80h |
| 80 | 1.4.1.8.2 | Evaluate GPS Board & Antennae | 4d | 2002-03-29 | 2002-04-03 | 79 | 35d | 0d | Craig | 32h |
| 81 | 1.4.1.8.3 | Purchase GPS Board & Antennae | 1d | 2002-04-04 | 2002-04-04 | 80 | 35d |  | Drew | 8h |
| 82 | 1.4.1.9 | Eval and Purchase 10/100 Hub | 2d | 2002-03-15 | 2002-03-18 |  | 58d |  | Sib | 16h |
| 83 | 1.4.1.10 | Eval & Purchase AHRS | 2d | 2002-03-15 | 2002-03-18 |  | 58d |  | Drew | 16h |
| 84 | 1.4.1.11 | Eval and Purchase LBL Board Set | 10d | 2002-03-15 | 2002-03-28 |  | 50d |  | Hans | 80h |
| 85 | 1.4.1.12 | Spec and Purcahse DVL | 5d | 2002-03-15 | 2002-03-21 |  | 55d |  | Rob | 40h |

| ID | WBS | Task | Duration | Start | Finish | Predecessors | Total slack | Free slack | Resources | Work |
| --- | --- | --- | --- | --- | --- | --- | --- | --- | --- | --- |
| 86 | 1.4.2 | **MVC Housing** | 23d? | 2002-03-15 | 2002-04-16 |  | 27d |  | Drew | 368h |
| 87 | 1.4.2.1 | Spec Interconnects | 5d | 2002-03-15 | 2002-03-21 |  | 27d | 0d | Drew | 40h |
| 88 | 1.4.2.2 | Design | 5d | 2002-03-22 | 2002-03-28 | 87 | 27d | 0d | Farley | 40h |
| 89 | 1.4.2.3 | Build/Purchase | 10d | 2002-03-29 | 2002-04-11 | 88 | 27d | 0d | Shop | 80h |
| 90 | 1.4.2.4 | Pressure Test | 2d | 2002-04-12 | 2002-04-15 | 89 | 27d | 0d | ME TECH | 16h |
| 91 | 1.4.2.5 | Electronics Packagin Layout | 1d? | 2002-04-16 | 2002-04-16 | 90 | 27d | 6d | Drew | 8h |
| 92 | 1.4.3 | **Documentation Package** | 10d | 2002-04-25 | 2002-05-08 | 91, 78, 75, 66 | 21d |  | Sib | 192h |
| 93 | 1.4.3.1 | Mechanical | 2d | 2002-04-25 | 2002-04-26 |  | 27d | 6d | Farley | 16h |
| 94 | 1.4.3.2 | Electrical | 8d | 2002-04-25 | 2002-05-06 |  | 21d | 0d | Sib | 64h |
| 95 | 1.4.3.3 | Software | 2d | 2002-04-25 | 2002-04-26 |  | 27d | 6d | Hans | 16h |
| 96 | 1.4.3.4 | Integration | 2d | 2002-05-07 | 2002-05-08 | 94, 95, 93 | 21d |  | Sib | 16h |
| 98 | 1.5 | **Navigation Hardware & Testing** | 30d | 2002-03-15 | 2002-04-25 |  | 30d |  | Hans | 840h |
| 99 | 1.5.1 | **Deep Water testing of USBL** | 15d | 2002-03-15 | 2002-04-04 |  | 30d | 0d | Hans | 240h |
| 100 | 1.5.1.1 | Tank testing | 10d | 2002-03-15 | 2002-03-28 |  | 30d | 0d | Hans | 80h |
| 101 | 1.5.1.2 | At Sea Testing | 5d | 2002-03-29 | 2002-04-04 | 100 | 30d |  | Hans | 40h |
| 102 | 1.5.2 | **Deep Water Testing of LBL Fish Mode** | 15d | 2002-04-05 | 2002-04-25 | 99 | 30d |  | Hans | 240h |
| 103 | 1.5.2.1 | Tank Testing | 10d | 2002-04-05 | 2002-04-18 |  | 30d | 0d | Hans | 80h |
| 104 | 1.5.2.2 | At Sea Testing | 5d | 2002-04-19 | 2002-04-25 | 103 | 30d |  | Hans | 40h |
| 105 | 1.5.3 | Radio Range for modems | 5d | 2002-03-15 | 2002-03-21 |  | 55d |  | Drew | 40h |
| 106 | 1.5.4 | RDF Ranging | 5d | 2002-03-15 | 2002-03-21 |  | 50d | 0d | Drew | 40h |
| 107 | 1.5.5 | Eval Zephyr RDF capability | 5d | 2002-03-22 | 2002-03-28 | 106 | 50d |  | Drew | 40h |
| 109 | 1.6 | **Fiarings / Vehicle Mechanical Structure** | 52d | 2002-03-15 | 2002-05-27 |  | 8d |  | Drew | 2432h |
| 110 | 1.6.1 | **L&R System Interface** | 36d | 2002-03-15 | 2002-05-03 |  | 24d |  | Drew | 608h |
| 111 | 1.6.1.1 | Prelim Concept w/ Brook ocean | 5d | 2002-03-15 | 2002-03-21 |  | 24d | 0d | Farley | 40h |
| 112 | 1.6.1.2 | Concept Design Review / Decision | 1d | 2002-03-22 | 2002-03-22 | 111 | 24d | 0d | Farley | 8h |
| 113 | 1.6.1.3 | Design L&R Interface | 10d | 2002-03-25 | 2002-04-05 | 112 | 24d | 0d | Farley | 80h |
| 114 | 1.6.1.4 | Build Interface | 10d | 2002-04-08 | 2002-04-19 | 113 | 24d | 0d | Shop | 80h |
| 115 | 1.6.1.5 | Assemble Interface | 5d | 2002-04-22 | 2002-04-26 | 114 | 24d | 0d | ME TECH | 40h |
| 116 | 1.6.1.6 | L&R test plan | 4d | 2002-03-15 | 2002-03-20 |  | 51d | 27d | Drew | 32h |
| 117 | 1.6.1.7 | Integrate and Test L&R Interface | 5d | 2002-04-29 | 2002-05-03 | 116, 115 | 24d |  | Farley | 40h |

| ID | WBS | Task | Duration | Start | Finish | Predecessors | Total slack | Free slack | Resources | Work |
| --- | --- | --- | --- | --- | --- | --- | --- | --- | --- | --- |
| 118 | 1.6.2 | **Joining Ring/Systems** | 34d | 2002-03-15 | 2002-05-01 |  | 8d | 0d | Drew | 544h |
| 119 | 1.6.2.1 | Evaluate joining ring systems | 2d | 2002-03-15 | 2002-03-18 |  | 8d | 0d | Farley | 16h |
| 120 | 1.6.2.2 | Review Concept | 1d | 2002-03-19 | 2002-03-19 | 119 | 8d | 0d | Farley | 8h |
| 121 | 1.6.2.3 | Final Design | 15d | 2002-03-20 | 2002-04-09 | 120 | 8d | 0d | Farley | 120h |
| 122 | 1.6.2.4 | Build | 10d | 2002-04-10 | 2002-04-23 | 121 | 8d | 0d | Shop | 80h |
| 123 | 1.6.2.5 | Assemble | 3d | 2002-04-24 | 2002-04-26 | 122 | 8d | 0d | ME TECH | 24h |
| 124 | 1.6.2.6 | Test | 3d | 2002-04-29 | 2002-05-01 | 123 | 8d |  | Drew | 24h |
| 125 | 1.6.3 | **Deck Handling Equipment** | 10d | 2002-05-14 | 2002-05-27 | 139 | 8d |  | Drew | 336h |
| 126 | 1.6.3.1 | New Cart Design | 5d | 2002-05-14 | 2002-05-20 |  | 13d |  | ME TECH | 40h |
| 127 | 1.6.3.2 | New Lifitng Gear | 5d | 2002-05-14 | 2002-05-20 |  | 13d |  | ME TECH | 40h |
| 128 | 1.6.3.3 | Sphere Lift Mechanism | 10d | 2002-05-14 | 2002-05-27 |  | 8d |  | Farley | 80h |
| 129 | 1.6.3.4 | Eval Single Pt. Lift | 2d | 2002-05-14 | 2002-05-15 |  | 16d |  | Drew | 16h |
| 130 | 1.6.3.5 | Lifting I beam in Lab | 5d | 2002-05-14 | 2002-05-20 |  | 13d |  | ME TECH | 40h |
| 131 | 1.6.3.6 | Cable trays nad outlets in lab ceiling | 5d | 2002-05-14 | 2002-05-20 |  | 13d |  | ME TECH | 40h |
| 132 | 1.6.4 | **Sensor & Payload Mounts** | 3d | 2002-03-15 | 2002-03-19 |  | 39d | 31d | Drew | 72h |
| 133 | 1.6.4.1 | Antennaes | 3d | 2002-03-15 | 2002-03-19 |  | 39d |  | Drew | 24h |
| 134 | 1.6.4.2 | ORE & various equip | 3d | 2002-03-15 | 2002-03-19 |  | 39d |  | Drew | 24h |
| 135 | 1.6.5 | **Buoyancy** | 10d | 2002-03-15 | 2002-03-28 |  | 32d | 24d | Drew | 200h |
| 136 | 1.6.5.1 | Tailcone Foam Pack Specification | 5d | 2002-03-15 | 2002-03-21 |  | 32d | 0d | Farley | 40h |
| 137 | 1.6.5.2 | Tailcone foam machining | 5d | 2002-03-22 | 2002-03-28 | 136 | 32d |  | Farley | 40h |
| 138 | 1.6.5.3 | Modular trim / ballast systems concept | 5d | 2002-03-15 | 2002-03-21 |  | 37d |  | Rob | 40h |
| 139 | 1.6.6 | **Fairing Build** | 8d | 2002-05-02 | 2002-05-13 | 132, 135, 118 | 8d | 0d | Drew | 256h |
| 140 | 1.6.6.1 | Noes section (2 plus 1 spare) | 8d | 2002-05-02 | 2002-05-13 |  | 8d |  | ME TECH | 64h |
| 141 | 1.6.6.2 | Midboady (2 plus 1 spare) | 8d | 2002-05-02 | 2002-05-13 |  | 8d |  | ME TECH | 64h |
| 142 | 1.6.6.3 | Tail section (2 plus 1 spare) | 8d | 2002-05-02 | 2002-05-13 |  | 8d |  | ME TECH | 64h |

| ID | WBS | Task | Duration | Start | Finish | Predecessors | Total slack | Free slack | Resources | Work |
| --- | --- | --- | --- | --- | --- | --- | --- | --- | --- | --- |
| 144 | 1.7 | **Software** | 60d | 2002-03-15 | 2002-06-06 |  | 0d |  | Hans | 3664h |
| 145 | 1.7.1 | Change supervisor so drivers run all the time | 3d | 2002-03-15 | 2002-03-19 |  | 54d | 0d | Hans | 24h |
| 146 | 1.7.2 | Chang logging to convert files to MATLAB | 3d | 2002-03-20 | 2002-03-22 | 145 | 54d |  | Hans | 24h |
| 147 | 1.7.3 | **OS Upgrade** | 6d | 2002-03-15 | 2002-03-22 |  | 54d |  | Sib | 96h |
| 148 | 1.7.3.1 | QNX Upgrade to Neutrino | 3d | 2002-03-15 | 2002-03-19 |  | 54d | 0d | Sib | 24h |
| 149 | 1.7.3.2 | Eval Linux for possible upgrade in future | 3d | 2002-03-20 | 2002-03-22 | 148 | 54d |  | Sib | 24h |
| 150 | 1.7.4 | **GUI** | 50d | 2002-03-15 | 2002-05-23 |  | 10d |  | Rich | 800h |
| 151 | 1.7.4.1 | gather requirements | 5d | 2002-03-15 | 2002-03-21 |  | 10d | 0d | Rich | 40h |
| 152 | 1.7.4.2 | eval Bluefin GUI | 10d | 2002-03-22 | 2002-04-04 | 151 | 10d | 0d | Rich | 80h |
| 153 | 1.7.4.3 | develop GUI plan | 5d | 2002-04-05 | 2002-04-11 | 152 | 10d | 0d | Rich | 40h |
| 154 | 1.7.4.4 | Detail GUI development (TBD) | 30d | 2002-04-12 | 2002-05-23 | 153 | 10d |  | Rich | 240h |
| 155 | 1.7.5 | Configuration management on vehicle (config files) | 15d | 2002-03-15 | 2002-04-04 |  | 45d |  | Rich | 120h |
| 156 | 1.7.6 | **Controls** | 45d | 2002-03-15 | 2002-05-16 |  | 15d |  | Rob | 720h |
| 157 | 1.7.6.1 | depth control improvement (long configs) | 15d | 2002-03-15 | 2002-04-04 |  | 15d | 0d | Rob | 120h |
| 158 | 1.7.6.2 | sway / yaw control coupling (heave/ pitch too) | 10d | 2002-04-05 | 2002-04-18 | 157 | 15d | 0d | Rob | 80h |
| 159 | 1.7.6.3 | slow speed dynamics for control | 20d | 2002-04-19 | 2002-05-16 | 158 | 15d |  | Rob | 160h |
| 160 | 1.7.7 | **Navigation Software** | 60d | 2002-03-15 | 2002-06-06 |  | 0d |  | Hans | 1080h |
| 161 | 1.7.7.1 | Document current NAV sys | 15d | 2002-03-15 | 2002-04-04 |  | 0d |  | Hans | 120h |
| 162 | 1.7.7.2 | Streamline current nav architecture | 15d | 2002-04-05 | 2002-04-25 | 161 | 0d |  | Hans | 120h |
| 163 | 1.7.7.3 | Single beacon homing | 15d | 2002-04-26 | 2002-05-16 | 162 | 0d |  | Hans | 120h |
| 164 | 1.7.7.4 | Single beacon LBL | 15d | 2002-05-17 | 2002-06-06 | 163 | 0d |  | Hans | 120h |
| 165 | 1.7.7.5 | DVL driver enhancements for PD5 | 15d | 2002-04-26 | 2002-05-16 | 162 | 15d |  | Rob | 120h |
| 166 | 1.7.8 | **Intra-vehicle Comms** | 20d | 2002-03-15 | 2002-04-11 |  | 40d |  | Sib | 320h |
| 167 | 1.7.8.1 | set up socket code (for reconnects) | 5d | 2002-03-15 | 2002-03-21 |  | 40d | 0d | Hans | 40h |
| 168 | 1.7.8.2 | briding over wireless | 15d | 2002-03-22 | 2002-04-11 | 167 | 40d |  | Sib | 120h |

| ID | WBS | Task | Duration | Start | Finish | Predecessors | Total slack | Free slack | Resources | Work |
| --- | --- | --- | --- | --- | --- | --- | --- | --- | --- | --- |
| 170 | 1.8 | **Vehicle Integration and Test** | 33d | 2002-06-07 | 2002-07-23 | 3, 46, 109, 60, 98, 144 | 0d |  | Hans | 640h |
| 171 | 1.8.1 | Tailcone Assembly | 5d | 2002-06-07 | 2002-06-13 |  | 0d |  | Hans | 40h |
| 172 | 1.8.2 | Tailcone Test | 2d | 2002-06-14 | 2002-06-17 | 171 | 0d |  | Sib | 16h |
| 173 | 1.8.3 | Battery Midbody Integration | 5d | 2002-06-07 | 2002-06-13 |  | 0d |  | Hans | 40h |
| 174 | 1.8.4 | Battery Midbody Test | 2d | 2002-06-14 | 2002-06-17 | 173 | 0d |  | Sib | 16h |
| 175 | 1.8.5 | ALTEX Nose Payload Assembly/Upgrade | 5d | 2002-06-07 | 2002-06-13 |  | 0d |  | Drew | 40h |
| 176 | 1.8.6 | Payload Test | 2d | 2002-06-14 | 2002-06-17 | 175 | 0d |  | Drew | 16h |
| 177 | 1.8.7 | Integrated Vehcile Deck Assembly | 2d | 2002-06-18 | 2002-06-19 | 172, 174, 176 | 0d |  | Drew | 16h |
| 178 | 1.8.8 | Vehicle Ballasting | 1d | 2002-06-20 | 2002-06-20 | 177 | 0d |  | Drew | 8h |
| 179 | 1.8.9 | Integrated Vehicle Deck Test | 3d | 2002-06-21 | 2002-06-25 | 178 | 0d |  | Drew | 24h |
| 180 | 1.8.10 | Integrated Vehicle Tank Test | 10d | 2002-06-26 | 2002-07-09 | 179 | 0d |  | Drew | 80h |
| 181 | 1.8.11 | Integrated Vehicle Sea Trials | 10d | 2002-07-10 | 2002-07-23 | 180 | 0d |  | Drew | 80h |
| 183 | 1.9 | **CTD Science Payload Core** | 94d? | 2002-03-15 | 2002-07-24 |  | 20d |  | Drew | 992h |
| 184 | 1.9.1 | Repair/Replace nose fairing | 3d | 2002-03-15 | 2002-03-19 |  | 105d | 0d | ME TECH | 24h |
| 185 | 1.9.2 | recable Dcon to comms and pwr bus | 8d | 2002-03-15 | 2002-03-26 |  | 82d | 0d | EE TECH | 64h |
| 186 | 1.9.3 | Design HS2 Mount | 2d | 2002-03-20 | 2002-03-21 | 184 | 105d | 0d | ME TECH | 16h |
| 187 | 1.9.4 | Build HS2 Mount | 2d | 2002-03-22 | 2002-03-25 | 186 | 105d | 0d | ME TECH | 16h |
| 188 | 1.9.5 | Assembly HS2 Mount | 2d | 2002-03-26 | 2002-03-27 | 187 | 105d |  | ME TECH | 16h |
| 189 | 1.9.6 | Write test driver HS2 | 5d | 2002-03-15 | 2002-03-21 |  | 109d |  | Rich | 40h |
| 190 | 1.9.7 | Eval Foam buoyancy cooridnate 1500 M version | 5d | 2002-03-15 | 2002-03-21 |  | 109d |  | Farley | 40h |
| 191 | 1.9.8 | repair flow sensor #2 | 3d | 2002-03-27 | 2002-03-29 | 185 | 82d |  | EE TECH | 24h |
| 192 | 1.9.9 | test integrated CTD Payload | 1d? | 2002-07-24 | 2002-07-24 | 191, 170 | 0d |  |  |  |
| 194 | 1.10 | **CTD Extension for Ryan/Haddock** | 20d | 2002-07-25 | 2002-08-21 | 191, 144, 192 | 0d |  | Drew | 512h |
| 195 | 1.10.1 | Design LISST pump assy | 3d | 2002-07-25 | 2002-07-29 |  | 0d |  | Drew | 24h |
| 196 | 1.10.2 | Fab LISST pump assy | 5d | 2002-07-30 | 2002-08-05 | 195 | 3d | 0d | Shop | 40h |
| 197 | 1.10.3 | Assy LISST pump into vehicle | 2d | 2002-08-06 | 2002-08-07 | 196 | 3d |  | ME TECH | 16h |
| 198 | 1.10.4 | Design LISST mount | 5d | 2002-07-30 | 2002-08-05 | 195 | 0d |  | Farley | 40h |
| 199 | 1.10.5 | Fab LISST Mount | 5d | 2002-08-06 | 2002-08-12 | 198 | 0d |  | Shop | 40h |
| 200 | 1.10.6 | Assy LISST mount | 2d | 2002-08-13 | 2002-08-14 | 197, 199 | 0d |  | ME TECH | 16h |
| 201 | 1.10.7 | Cable LISST to Dcon | 1d | 2002-08-15 | 2002-08-15 | 200 | 4d |  | EE TECH | 8h |
| 202 | 1.10.8 | Write Test Driver for LISST | 5d | 2002-08-15 | 2002-08-21 | 200 | 0d |  | Rich | 40h |
| 203 | 1.10.9 | Design Bathypho mount | 5d | 2002-07-25 | 2002-07-31 |  | 4d | 0d | Drew | 40h |
| 204 | 1.10.10 | Fab Bathypho mount | 5d | 2002-08-01 | 2002-08-07 | 203 | 4d | 0d | ME TECH | 40h |
| 205 | 1.10.11 | Assy Bathypho mount | 2d | 2002-08-08 | 2002-08-09 | 204 | 4d | 0d | ME TECH | 16h |
| 206 | 1.10.12 | Cable Bathypho to Dcon | 1d | 2002-08-12 | 2002-08-12 | 205 | 4d | 0d | EE TECH | 8h |
| 207 | 1.10.13 | Retest driver for Bathypho (already written) | 3d | 2002-08-13 | 2002-08-15 | 206 | 4d |  | Rich | 24h |
